# You are beautiful w8

How a schedule from MS Project changed from version to version. A marks actual dates.

## Version 1 (saved 2014-05-26, file You are Beautiful w8.mpp)

| ID | WBS | Task | Duration | Start | Finish | Predecessors | Complete | Total float | Constraint |
| --- | --- | --- | --- | --- | --- | --- | --- | --- | --- |
| 1 | 1 | **Voorbereidingsfase** | 1.03d | 2013-09-10 16:00 A | 2013-09-25 15:15 A |  | 100% |  |  |
| 2 |  | Voorbereidend gesprek met opdrachtgever | 2h | 2013-09-10 16:00 A | 2013-09-10 18:00 A |  | 100% |  | must start on 2013-09-10 16:00 |
| 3 |  | Project bestand aanmaken | 2h | 2013-09-11 15:00 A | 2013-09-11 17:00 A | 2 | 100% |  |  |
| 4 | 1.3 | **Opdracht 1 Resultaten beschrijven** | 0.34d | 2013-09-12 15:00 A | 2013-09-18 15:45 A | 3 | 100% |  |  |
| 5 |  | Voorbereiden projectresultaat | 1.75h | 2013-09-12 15:00 A | 2013-09-12 16:45 A |  | 100% |  |  |
| 6 |  | Voorbereiden organisatieresultaat | 1.75h | 2013-09-12 15:00 A | 2013-09-12 16:45 A |  | 100% |  |  |
| 7 |  | Voorbereiden omgevingsresultaat | 1.75h | 2013-09-12 15:00 A | 2013-09-12 16:45 A |  | 100% |  |  |
| 8 |  | Voorbereiden bedrijfsresultaat | 1.75h | 2013-09-12 15:00 A | 2013-09-12 16:45 A |  | 100% |  |  |
| 9 |  | Bespreken projectresultaat | 0.25h | 2013-09-12 16:45 A | 2013-09-12 17:00 A | 5 | 100% |  |  |
| 10 |  | Bespreken organisatieresultaat | 0.25h | 2013-09-18 15:00 A | 2013-09-18 15:15 A | 6, 9 | 100% |  |  |
| 11 |  | Bespreken omgevingsresultaat | 0.25h | 2013-09-18 15:15 A | 2013-09-18 15:30 A | 7, 10 | 100% |  |  |
| 12 |  | Bespreken bedrijfsresultaat | 0.25h | 2013-09-18 15:30 A | 2013-09-18 15:45 A | 8, 11 | 100% |  |  |
| 13 |  | Opdracht 2 structurele inbedding | 0.5h | 2013-09-18 15:45 A | 2013-09-18 16:15 A | 4 | 100% |  |  |
| 14 | 1.5 | **Opdracht 3** | 0d | 2013-09-18 16:15 A | 2013-09-18 16:16 A | 13 | 100% |  |  |
| 15 |  | Belanghebbende in kaart brengen | 0.02h | 2013-09-18 16:15 A | 2013-09-18 16:16 A |  | 100% |  |  |
| 16 |  | Belang en verantwoordelijkheid in kaart brengen | 0.02h | 2013-09-18 16:15 A | 2013-09-18 16:16 A |  | 100% |  |  |
| 17 | 1.6 | **Opdracht 4** | 0.09d | 2013-09-18 16:16 A | 2013-09-19 15:00 A | 14 | 100% |  |  |
| 18 |  | krachtenveldanalyse | 0.73h | 2013-09-18 16:16 A | 2013-09-19 15:00 A |  | 100% |  |  |
| 19 |  | relevantieanalyse | 0.73h | 2013-09-18 16:16 A | 2013-09-19 15:00 A |  | 100% |  |  |
| 20 |  | houdingsanalyse | 0.73h | 2013-09-18 16:16 A | 2013-09-19 15:00 A |  | 100% |  |  |
| 21 |  | Invloed analyses | 0.73h | 2013-09-18 16:16 A | 2013-09-19 15:00 A |  | 100% |  |  |
| 22 | 1.7 | **Samenvatting resultaten tot nu toe** | 0.16d | 2013-09-19 15:00 A | 2013-09-19 16:15 A |  | 100% |  |  |
| 23 |  | Schrijven samenvatting | 1h | 2013-09-19 15:00 A | 2013-09-19 16:00 A | 14 | 100% |  |  |
| 24 |  | Kritisch bekijken samenvatting | 0.25h | 2013-09-19 16:00 A | 2013-09-19 16:15 A | 17, 23 | 100% |  |  |
| 25 |  | Voortgangsgesprek met de opdrachtgever | 1h | 2013-09-24 10:00 A | 2013-09-24 11:00 A |  | 100% |  | must start on 2013-09-24 10:00 |
| 26 |  | aanvragen project | 0.25h | 2013-09-25 15:00 A | 2013-09-25 15:15 A | 25 | 100% |  |  |
| 27 | 2 | **Definitiefase** | 2.47d | 2013-09-25 15:15 A | 2013-10-31 17:00 A | 1 | 100% |  |  |
| 28 |  | Planning definitiefase | 0.5h | 2013-09-25 15:15 A | 2013-09-25 15:45 A |  | 100% |  |  |
| 29 | 2.2 | **Opdracht 5** | 0.31d | 2013-09-25 15:45 A | 2013-09-26 16:15 A | 28 | 100% |  |  |
| 30 |  | Alternatief 1 | 0.5h | 2013-09-25 15:45 A | 2013-09-25 16:15 A |  | 100% |  |  |
| 31 |  | Alternatief 2 | 0.5h | 2013-09-25 16:15 A | 2013-09-25 16:45 A | 30 | 100% |  |  |
| 32 |  | Alternatief 3 | 0.5h | 2013-09-25 16:45 A | 2013-09-26 15:15 A | 31 | 100% |  |  |
| 33 |  | Uitwerking alternatief 1 | 1h | 2013-09-26 15:15 A | 2013-09-26 16:15 A | 32 | 100% |  |  |
| 34 |  | Uitwerking alternatief 2 | 1h | 2013-09-26 15:15 A | 2013-09-26 16:15 A | 32 | 100% |  |  |
| 35 |  | Uitwerking alternatief 3 | 1h | 2013-09-26 15:15 A | 2013-09-26 16:15 A | 32 | 100% |  |  |
| 36 | 2.3 | **Opdracht 6** | 0.09d | 2013-09-26 16:15 A | 2013-09-26 17:00 A | 29 | 100% |  |  |
| 37 |  | Projectplan stap 1 | 0.75h | 2013-09-26 16:15 A | 2013-09-26 17:00 A |  | 100% |  |  |
| 38 | 2.4 | **Opdracht 7** | 1.12d | 2013-10-02 15:00 A | 2013-10-23 16:00 A | 36 | 100% |  | start no earlier than 2013-09-30 08:00 |
| 39 |  | WBS maken | 4h | 2013-10-02 15:00 A | 2013-10-03 17:00 A |  | 100% |  |  |
| 40 |  | Producten project | 1h | 2013-10-09 16:00 A | 2013-10-09 17:00 A | 39, 42 | 100% |  |  |
| 41 |  | PBS maken | 3h | 2013-10-10 15:00 A | 2013-10-23 16:00 A | 40 | 100% |  |  |
| 42 |  | Afspraak 1 Joyce | 1h | 2013-10-09 15:00 A | 2013-10-09 16:00 A |  | 100% |  | must start on 2013-10-09 15:00 |
| 43 | 2.5 | **opdracht 8** | 0.5d | 2013-10-23 16:00 A | 2013-10-30 16:00 A | 38 | 100% |  |  |
| 44 |  | Inventarisatie risico's | 2h | 2013-10-23 16:00 A | 2013-10-24 16:00 A |  | 100% |  |  |
| 45 |  | Inschatting risico's | 1h | 2013-10-24 16:00 A | 2013-10-24 17:00 A | 44 | 100% |  |  |
| 46 |  | Tegen maatregelen bedenken | 1h | 2013-10-30 15:00 A | 2013-10-30 16:00 A | 45 | 100% |  |  |
| 47 | 2.6 | **Projectplan** | 0.25d | 2013-10-30 16:00 A | 2013-10-31 16:00 A | 43 | 100% |  |  |
| 48 |  | Concept projectplan | 1h | 2013-10-30 16:00 A | 2013-10-30 17:00 A |  | 100% |  |  |
| 49 |  | Eind versie Projectplan | 1h | 2013-10-31 15:00 A | 2013-10-31 16:00 A | 48 | 100% |  |  |
| 50 |  | Evaluatie definitiefase | 1h | 2013-10-31 16:00 A | 2013-10-31 17:00 A | 47 | 100% |  |  |
| 51 | 3 | **Uitvoeringsfase** | 56.62d? | 2013-11-11 09:00 | 2014-02-10 12:00 |  |  | -45d | start no earlier than 2013-11-11 08:00 |
| 52 | 3.1 | **Werven/voorbereiden/regelen** | 45d? | 2013-11-11 09:00 | 2014-01-24 17:00 |  |  | -45d |  |
| 53 |  | Rode kruis | 9w | 2013-11-11 09:00 | 2014-01-24 17:00 |  |  | -6.12d |  |
| 54 |  | Verstandelijk beperkten | 6w | 2013-11-11 09:00 | 2013-12-20 17:00 |  |  | 8.88d |  |
| 55 |  | Vrijwilligers | 9w | 2013-11-11 09:00 | 2014-01-24 17:00 |  |  | -6.12d |  |
| 56 |  | Sponsors | 9w | 2013-11-11 09:00 | 2014-01-24 17:00 |  |  | -6.12d |  |
| 57 |  | Subsidie | 3w | 2013-11-11 09:00 | 2013-11-29 17:00 |  |  | 23.88d |  |
| 58 |  | Locatie | 6w | 2013-11-11 09:00 | 2013-12-20 17:00 |  |  | 8.88d |  |
| 59 | 3.1.7 | **Specialisten** | 45d? | 2013-11-11 09:00 | 2014-01-24 17:00 |  |  | -45d |  |
| 60 |  | Presentator | 9w | 2013-11-11 09:00 | 2014-01-24 17:00 |  |  | -6.12d |  |
| 61 |  | Visagisten/kappers | 9w | 2013-11-11 09:00 | 2014-01-24 17:00 |  |  | -6.12d |  |
| 62 | 3.1.7.3 | **Fotograaf** | 45d | 2013-11-11 09:00 | 2014-01-24 17:00 |  |  | -6.12d |  |
| 63 |  | Zoeken | 9w | 2013-11-11 09:00 | 2014-01-24 17:00 |  |  | -6.12d |  |
| 64 |  | afspraken | 9w | 2013-11-11 09:00 | 2014-01-24 17:00 |  |  | -6.12d |  |
| 65 |  | Pers | 9w | 2013-11-11 09:00 | 2014-01-24 17:00 |  |  | -6.12d |  |
| 66 | 3.1.7.5 | **Catering** | 0d? | 2013-11-11 09:00 | 2013-11-11 09:00 |  |  |  |  |
| 67 |  | Offertes aanvragen | 6w | 2013-11-11 09:00 | 2013-12-20 17:00 |  |  | -45d |  |
| 68 |  | Offertes selecteren | 2w | 2014-01-06 09:00 | 2014-01-17 17:00 | 67 |  | -45d |  |
| 69 |  | Contract cateraar | 1w | 2014-01-20 09:00 | 2014-01-24 17:00 | 68 |  | -45d |  |
| 70 | 3.1.8 | **Materialen** | 45d | 2013-11-11 09:00 | 2014-01-24 17:00 |  |  | -6.12d |  |

| ID | WBS | Task | Duration | Start | Finish | Predecessors | Total float | Constraint |
| --- | --- | --- | --- | --- | --- | --- | --- | --- |
| 71 |  | Kleding | 6w | 2013-11-11 09:00 | 2013-12-20 17:00 |  | 8.88d |  |
| 72 |  | Rode loper | 9w | 2013-11-11 09:00 | 2014-01-24 17:00 |  | -6.12d |  |
| 73 |  | Versiering | 3w | 2014-01-06 09:00 | 2014-01-24 17:00 |  | -6.12d | start no earlier than 2014-01-06 09:00 |
| 74 |  | Muziek | 3w | 2014-01-06 09:00 | 2014-01-24 17:00 |  | -6.12d | start no earlier than 2014-01-06 09:00 |
| 75 |  | Goodiebag | 9w | 2013-11-11 09:00 | 2014-01-24 17:00 |  | -6.12d |  |
| 76 | 3.2 | **Inrichten** | 5.72d | 2014-02-03 09:00 | 2014-02-08 13:45 |  | -11.53d |  |
| 77 |  | Ophalen spullen | 3h | 2014-02-03 09:00 | 2014-02-03 12:00 |  | -11.5d | start no earlier than 2014-02-03 08:00 |
| 78 |  | Opbouwen | 2h | 2014-02-08 08:00 | 2014-02-08 10:00 |  | -16.38d | start no earlier than 2014-02-08 08:00 |
| 79 |  | Klaarmaken lunch | 2h | 2014-02-08 08:00 | 2014-02-08 10:00 |  | -16.38d | start no earlier than 2014-02-08 08:00 |
| 80 |  | Aankomst vrijwilligers | 2h | 2014-02-08 08:00 | 2014-02-08 10:00 |  | -16.38d | start no earlier than 2014-02-08 08:00 |
| 81 |  | Aankomst verstandelijk beperkten en begeleiders | 30min | 2014-02-08 10:00 | 2014-02-08 10:30 |  | 0d | must start on 2014-02-08 10:00 |
| 82 |  | Omkleden 1 | 70min | 2014-02-08 10:30 | 2014-02-08 11:40 | 81 | -16.84d |  |
| 83 |  | Generale repetitie | 70min | 2014-02-08 11:40 | 2014-02-08 12:50 | 82 | -16.84d |  |
| 84 |  | Pauze | 10min | 2014-02-08 12:50 | 2014-02-08 13:00 | 83 | -16.84d |  |
| 85 |  | Lunch | 45min | 2014-02-08 13:00 | 2014-02-08 13:45 | 84 | -16.84d |  |
| 86 | 3.3 | **Uitvoering modeshow** | 0.25d | 2014-02-08 14:00 | 2014-02-08 16:00 |  | -17.5d | start no earlier than 2014-02-08 14:00 |
| 87 |  | Openingswoord door organisatoren | 10min | 2014-02-08 14:00 | 2014-02-08 14:10 |  | -17.5d |  |
| 88 |  | Start modeshow ronde 1 (groep 1 en 2) | 20min | 2014-02-08 14:10 | 2014-02-08 14:30 | 87 | -17.5d |  |
| 89 |  | Act verzorgt door meneer Vermeulen | 20min | 2014-02-08 14:30 | 2014-02-08 14:50 | 88 | -17.5d |  |
| 90 |  | Pauze | 10min | 2014-02-08 14:50 | 2014-02-08 15:00 | 89 | -17.5d |  |
| 91 |  | Modeshow ronde 2 (groep 3, 4 en 5) | 45min | 2014-02-08 15:00 | 2014-02-08 15:45 | 90 | -17.5d |  |
| 92 |  | Buiging en afsluiting | 15min | 2014-02-08 15:45 | 2014-02-08 16:00 | 91 | -17.5d |  |
| 93 | 3.4 | **Afsluiten** | 0.62d | 2014-02-08 16:00 | 2014-02-10 12:00 | 86 | -17.75d |  |
| 94 |  | Afbreken | 2h | 2014-02-08 16:00 | 2014-02-08 18:00 |  | -17.38d |  |
| 95 |  | Omkleden 2 | 2h | 2014-02-08 16:00 | 2014-02-08 18:00 |  | -17.38d |  |
| 96 |  | Terugbrengen spullen | 3h | 2014-02-10 09:00 | 2014-02-10 12:00 |  | -17.75d | start no earlier than 2014-02-10 08:00 |
| 97 | 4 | **Nazorgfase** | 0.12d | 2014-02-10 12:00 | 2014-02-10 13:00 | 51 | -17.75d |  |
| 98 |  | Projectverslag | 1h | 2014-02-10 12:00 | 2014-02-10 13:00 |  | -17.75d |  |

## Version 2 (saved 2014-05-26, file You are Beautiful w9.mpp)

Last finish 2014-02-10 → 2014-02-19 (+9d). Complete tasks 39 → 83.

Added:

| ID | Task | Duration | Start | Finish | Predecessors | Constraint | Resources |
| --- | --- | --- | --- | --- | --- | --- | --- |
| 54 | Overleg | 9w | 2013-11-11 09:00 A | 2014-01-24 17:00 A |  |  | Cédric Cortenraad; Corine Somers; Nicole van Ham; Roosmarijn Doedens |
| 55 | mailen | 9w | 2013-11-11 09:00 A | 2014-01-24 17:00 A |  |  | Nicole van Ham |
| 56 | bellen | 9w | 2013-11-11 09:00 A | 2014-01-24 17:00 A |  |  | Nicole van Ham |
| 58 | Pluryn | 6w | 2013-11-11 09:00 A | 2013-12-20 17:00 A |  |  | Cédric Cortenraad; Roosmarijn Doedens |
| 59 | Overige | 6w | 2013-11-11 09:00 A | 2013-12-20 17:00 A |  |  | Corine Somers; Nicole van Ham |
| 61 | Pluryn | 6w | 2013-11-11 09:00 A | 2013-12-20 17:00 A |  |  | Cédric Cortenraad; Roosmarijn Doedens |
| 62 | Overige | 6w | 2013-11-11 09:00 A | 2013-12-20 17:00 A |  |  | Roosmarijn Doedens |
| 64 | Rabobank | 6w | 2013-11-11 09:00 A | 2013-12-20 17:00 A |  |  | Corine Somers; Roosmarijn Doedens |
| 65 | ABN AMRO | 6w | 2013-11-11 09:00 A | 2013-12-20 17:00 A |  |  | Corine Somers; Roosmarijn Doedens |
| 66 | HAN | 6w | 2013-11-11 09:00 A | 2013-12-20 17:00 A |  |  | Corine Somers; Roosmarijn Doedens |
| 67 | Overige | 9w | 2013-11-11 09:00 A | 2014-01-24 17:00 A |  |  | Corine Somers; Roosmarijn Doedens |
| 70 | Kolpinghuis | 3w | 2013-11-11 09:00 A | 2013-11-29 17:00 A |  |  | Nicole van Ham |
| 71 | Dansschool vermeulen | 3w | 2013-12-02 09:00 A | 2013-12-20 17:00 A | 70 |  | Cédric Cortenraad; Roosmarijn Doedens |
| 110 | Eigen evaluatie | 1w | 2014-02-10 12:00 | 2014-02-17 12:00 |  |  | Cédric Cortenraad; Corine Somers; Nicole van Ham; Roosmarijn Doedens |
| 111 | Eindgesprek Rode Kruis | 1h | 2014-02-19 14:00 | 2014-02-19 15:00 |  | start no earlier than 2014-02-19 14:00 | Cédric Cortenraad; Corine Somers; Kimberly van der Laan; Nicole van Ham; Roosmarijn Doedens |
| 113 | Eindgesprek Joyce | 1d? | 2014-02-10 12:00 | 2014-02-11 12:00 |  |  |  |

Removed: 80 Aankomst vrijwilligers

Changed:

| ID | Task | Start | Finish | Duration | Complete | Total float | Other |
| --- | --- | --- | --- | --- | --- | --- | --- |
| 51 | **Uitvoeringsfase** | 2013-11-11 09:00 A | 2014-02-10 12:00 A |  | 0% → 100% | -45d → none |  |
| 52 | **Werven/voorbereiden/regelen** | 2013-11-11 09:00 A | 2014-01-24 17:00 A |  | 0% → 100% | -45d → none |  |
| 53 | **Rode kruis** | 2013-11-11 09:00 A | 2014-01-24 17:00 A | 9w → 45d | 0% → 100% | -6.12d → none | resources Cédric Cortenraad; Corine Somers; Nicole van Ham; Roosmarijn Doedens → none |
| 57 | **Verstandelijk beperkten** | 2013-11-11 09:00 A | 2013-12-20 17:00 A | 6w → 30d | 0% → 100% | 8.88d → none | resources Nicole van Ham; Corine Somers → none |
| 60 | **Vrijwilligers** | 2013-11-11 09:00 A | 2014-01-24 17:00 → 2013-12-20 17:00 A (-35d) | 9w → 30d | 0% → 100% | -6.12d → none | resources Cédric Cortenraad; Corine Somers; Nicole van Ham; Roosmarijn Doedens → none |
| 63 | **Sponsors** | 2013-11-11 09:00 A | 2014-01-24 17:00 A | 9w → 45d | 0% → 100% | -6.12d → none | resources Corine Somers; Roosmarijn Doedens → none |
| 68 | Subsidie | 2013-11-11 09:00 A | 2013-11-29 17:00 A |  | 0% → 100% | 23.88d → none | resources Cédric Cortenraad → Roosmarijn Doedens |
| 69 | **Locatie** | 2013-11-11 09:00 A | 2013-12-20 17:00 A | 6w → 30d | 0% → 100% | 8.88d → none | resources Nicole van Ham → none |
| 72 | **Specialisten** | 2013-11-11 09:00 A | 2014-01-24 17:00 A |  | 0% → 100% | -45d → none |  |
| 73 | Presentator | 2013-11-11 09:00 A | 2014-01-24 17:00 A |  | 0% → 100% | -6.12d → none |  |
| 74 | Visagisten/kappers | 2013-11-11 09:00 A | 2014-01-24 17:00 A |  | 0% → 100% | -6.12d → none |  |
| 75 | **Fotograaf** | 2013-11-11 09:00 A | 2014-01-24 17:00 A |  | 0% → 100% | -6.12d → none |  |
| 76 | Zoeken | 2013-11-11 09:00 A | 2014-01-24 17:00 A |  | 0% → 100% | -6.12d → none |  |
| 77 | afspraken | 2013-11-11 09:00 A | 2014-01-24 17:00 A |  | 0% → 100% | -6.12d → none |  |
| 78 | Pers | 2013-11-11 09:00 A | 2014-01-24 17:00 A |  | 0% → 100% | -6.12d → none |  |
| 79 | **Catering** | 2013-11-11 09:00 A |  |  | 0% → 100% |  |  |
| 80 | Offertes aanvragen | 2013-11-11 09:00 A | 2013-12-20 17:00 A |  | 0% → 100% | -45d → none |  |
| 81 | Offertes selecteren | 2014-01-06 09:00 A | 2014-01-17 17:00 A |  | 0% → 100% | -45d → none |  |
| 82 | Contract cateraar | 2014-01-20 09:00 A | 2014-01-24 17:00 A |  | 0% → 100% | -45d → none |  |
| 83 | **Materialen** | 2013-11-11 09:00 A | 2014-01-24 17:00 A |  | 0% → 100% | -6.12d → none |  |
| 84 | Kleding | 2013-11-11 09:00 A | 2013-12-20 17:00 A |  | 0% → 100% | 8.88d → none | resources Cédric Cortenraad; Corine Somers; Nicole van Ham; Roosmarijn Doedens → Cédric Cortenraad; Roosmarijn Doedens |
| 85 | Rode loper | 2013-11-11 09:00 A | 2014-01-24 17:00 A |  | 0% → 100% | -6.12d → none |  |
| 86 | Versiering | 2014-01-06 09:00 A | 2014-01-24 17:00 A |  | 0% → 100% | -6.12d → none |  |
| 87 | Muziek | 2014-01-06 09:00 A | 2014-01-24 17:00 A |  | 0% → 100% | -6.12d → none |  |
| 88 | Goodiebag | 2013-11-11 09:00 A | 2014-01-24 17:00 A |  | 0% → 100% | -6.12d → none |  |
| 89 | **Inrichten** | 2014-02-03 09:00 A | 2014-02-08 13:45 A |  | 0% → 100% | -11.53d → none |  |
| 90 | Ophalen spullen | 2014-02-03 09:00 A | 2014-02-03 12:00 A |  | 0% → 100% | -11.5d → none | resources none → Corine Somers; Benodigheden kapper/visagist [0.1%]; Broodjes smeerders; Goodiebags [0.1%]; Eten/ drinken/bekers/borden [0.1%]; Kleding; Rode Loper; Versiering [0.1%] |
| 91 | Opbouwen | 2014-02-08 08:00 A | 2014-02-08 10:00 A |  | 0% → 100% | -16.38d → none | resources none → Cédric Cortenraad; Corine Somers; Nicole van Ham; Roosmarijn Doedens |
| 92 | Klaarmaken lunch | 2014-02-08 08:00 A | 2014-02-08 10:00 A |  | 0% → 100% | -16.38d → none | resources none → Broodjes smeerders [200%]; Eten/ drinken/bekers/borden [0.1%] |
| 93 | Aankomst verstandelijk beperkten en begeleiders | 2014-02-08 10:00 A | 2014-02-08 10:30 A |  | 0% → 100% | 0d → none | resources none → Verstandelijk beperkten [2900%]; Vrijwilligers [2500%] |
| 94 | Omkleden 1 | 2014-02-08 10:30 A | 2014-02-08 11:40 A |  | 0% → 100% | -16.84d → none | resources none → Verstandelijk beperkten [2900%]; Vrijwilligers [2500%]; Kapper [800%]; visagist [800%]; Benodigheden kapper/visagist [0.1%] |
| 95 | Generale repetitie | 2014-02-08 11:40 A | 2014-02-08 12:50 A |  | 0% → 100% | -16.84d → none | resources none → Verstandelijk beperkten [2900%]; Vrijwilligers [2500%] |
| 96 | Pauze | 2014-02-08 12:50 A | 2014-02-08 13:00 A |  | 0% → 100% | -16.84d → none | resources none → Koffie [0.1%] |
| 97 | Lunch | 2014-02-08 13:00 A | 2014-02-08 13:45 A |  | 0% → 100% | -16.84d → none | resources none → Verstandelijk beperkten [2900%]; Vrijwilligers [2500%]; Eten/ drinken/bekers/borden [0.1%] |
| 98 | **Uitvoering modeshow** | 2014-02-08 14:00 A | 2014-02-08 16:00 A |  | 0% → 100% | -17.5d → none | resources none → Verstandelijk beperkten [2900%]; Vrijwilligers [2500%]; Dansschool Vermeulen; Fotograaf; Presentator Joost Brauwer; Kleding; Rode Loper; Versiering [0.1%]; Muziek; Goodiebags [0.1%] |
| 99 | Openingswoord door organisatoren | 2014-02-08 14:00 A | 2014-02-08 14:10 A |  | 0% → 100% | -17.5d → none | resources none → Cédric Cortenraad; Corine Somers; Nicole van Ham; Roosmarijn Doedens |
| 100 | Start modeshow ronde 1 (groep 1 en 2) | 2014-02-08 14:10 A | 2014-02-08 14:30 A |  | 0% → 100% | -17.5d → none | resources none → Verstandelijk beperkten [1400%] |
| 101 | Act verzorgt door meneer Vermeulen | 2014-02-08 14:30 A | 2014-02-08 14:50 A |  | 0% → 100% | -17.5d → none | resources none → Vermeulen |
| 102 | Pauze | 2014-02-08 14:50 A | 2014-02-08 15:00 A |  | 0% → 100% | -17.5d → none |  |
| 103 | Modeshow ronde 2 (groep 3, 4 en 5) | 2014-02-08 15:00 A | 2014-02-08 15:45 A |  | 0% → 100% | -17.5d → none | resources none → Verstandelijk beperkten [1500%] |
| 104 | Buiging en afsluiting | 2014-02-08 15:45 A | 2014-02-08 16:00 A |  | 0% → 100% | -17.5d → none | resources none → Cédric Cortenraad; Corine Somers; Nicole van Ham; Roosmarijn Doedens |
| 105 | **Afsluiten** | 2014-02-08 16:00 A | 2014-02-10 12:00 A |  | 0% → 100% | -17.75d → none |  |
| 106 | Afbreken | 2014-02-08 16:00 A | 2014-02-08 18:00 A |  | 0% → 100% | -17.38d → none | resources none → Cédric Cortenraad; Corine Somers; Nicole van Ham; Roosmarijn Doedens |
| 107 | Omkleden 2 | 2014-02-08 16:00 A | 2014-02-08 18:00 A |  | 0% → 100% | -17.38d → none | resources none → Verstandelijk beperkten [2900%]; Vrijwilligers [2500%]; Kapper [800%]; visagist [800%] |
| 108 | Terugbrengen spullen | 2014-02-10 09:00 A | 2014-02-10 12:00 A |  | 0% → 100% | -17.75d → none | resources none → Corine Somers |
| 109 | **Nazorgfase** |  | 2014-02-10 13:00 → 2014-02-19 15:00 (+9d) | 0.12d → 7.38d? |  |  |  |

## Version 3 (saved 2014-05-26, file You are Beautiful w10.mpp)

Last finish 2014-02-19 → 2014-02-27 (+8d). Complete tasks 83 → 87.

Changed:

| ID | Task | Start | Finish | Duration | Complete | Total float | Predecessors | Other |
| --- | --- | --- | --- | --- | --- | --- | --- | --- |
| 109 | **Nazorgfase** | 2014-02-10 12:00 A | 2014-02-19 15:00 → 2014-02-27 17:00 A (+8d) | 7.38d? → 13.62d | 0% → 100% | -17.75d → none |  |  |
| 110 | Eigen evaluatie | 2014-02-10 12:00 A | 2014-02-17 12:00 A |  | 0% → 100% | 2.38d → none |  |  |
| 111 | Eindgesprek Rode Kruis | 2014-02-19 14:00 A | 2014-02-19 15:00 A |  | 0% → 100% | 0d → none |  |  |
| 112 | Projectverslag | 2014-02-10 12:00 → 2014-02-19 15:00 A (+9d) | 2014-02-10 13:00 → 2014-02-21 15:00 A (+11d) | 1h → 2d | 0% → 100% | -17.75d → none | none → 111 | resources none → Cédric Cortenraad; Corine Somers; Nicole van Ham; Roosmarijn Doedens |
| 113 | Eindgesprek Joyce | 2014-02-10 12:00 → 2014-02-27 16:00 A (+17d) | 2014-02-11 12:00 → 2014-02-27 17:00 A (+16d) | 1d? → 1h | 0% → 100% | 6.38d → none |  | constraint none → start no earlier than 2014-02-27 16:00; resources none → Cédric Cortenraad; Corine Somers; Joyce Bruil; Nicole van Ham; Roosmarijn Doedens |
